# ECP53_WTR_R1

Schedule from MS Project, 2007-01-02 to 2007-07-27.

## Calendars

- Standard: Mon-Fri 08:00-12:00, 13:00-17:00; Sat-Sun off.

## Resources

| Resource |
| --- |
| Dudek |
| Fan |
| Williamson |
| Gettelfinger |
| Gettlefinger |
| Brooks |
| Viola |

## Schedule

| ID | WBS | Task | Duration | Start | Finish | Predecessors | Baseline start | Baseline finish | Baseline duration | Total slack | Free slack | Constraint | Resources | Work |
| --- | --- | --- | --- | --- | --- | --- | --- | --- | --- | --- | --- | --- | --- | --- |
| 1 | 1 | **Bladder tests** | 63d | 2007-01-11 | 2007-04-09 |  | 2007-01-22 | 2007-04-09 | 56d | 79d |  |  |  | 608h |
| 2 | 1.1 | Define test plan. Set up test fixture. Order bladders, fill materials, and candidate epoxies for bladder tests. | 10d | 2007-01-22 | 2007-02-02 |  | 2007-01-22 | 2007-02-02 | 10d | 79d | 0d | start no earlier than 2007-01-22 | Dudek | 80h |
| 3 | 1.2 | Perform bench test of Teflon bladder to determine properties | 5d | 2007-02-05 | 2007-02-09 | 2 | 2007-02-05 | 2007-02-09 | 5d | 79d | 0d | start no earlier than 2007-01-12 | Dudek | 40h |
| 4 | 1.3 | Procure/fab prototype bladder for C-C installation | 10d | 2007-02-12 | 2007-02-23 | 3 | 2007-02-12 | 2007-02-23 | 10d | 110d |  |  | Dudek | 80h |
| 5 | 1.4 | Review structural analyses to determine bladder performance requirements. Verify adequate performance of Teflon bladder. | 5d | 2007-02-12 | 2007-02-16 | 3 | 2007-02-12 | 2007-02-16 | 5d | 79d | 0d | start no earlier than 2007-01-22 | Fan | 40h |
| 6 | 1.5 | Determine if "one size fits all". Develop procurement drawings for bladder. | 10d | 2007-01-22 | 2007-02-02 |  | 2007-01-22 | 2007-02-02 | 10d | 89d | 10d | start no earlier than 2007-01-22 | Williamson | 80h |
| 7 | 1.6 | Conduct FDR of bladder design | 1d | 2007-02-19 | 2007-02-19 | 6, 5 | 2007-02-19 | 2007-02-19 | 1d | 79d | 0d |  | Williamson | 8h |
| 8 | 1.7 | Resolve FDR issues, release procurement drawings for fabrication | 5d | 2007-02-20 | 2007-02-26 | 7 | 2007-02-20 | 2007-02-26 | 5d | 79d | 0d |  | Williamson | 40h |
| 9 | 1.8 | Procure bladders | 30d | 2007-02-27 | 2007-04-09 | 8 | 2007-02-27 | 2007-04-09 | 30d | 79d |  |  | Dudek | 240h |
| 11 | 2 | **Coefficient of friction (COF) tests** | 45d | 2007-01-02 | 2007-03-05 |  | 2007-01-02 | 2007-03-05 | 45d | 24d |  |  |  | 440h |
| 12 | 2.1 | Order candidate materials for screening tests. Perform screening tests. | 15d | 2007-01-02 | 2007-01-22 |  | 2007-01-02 | 2007-01-22 | 15d | 24d | 0d | start no earlier than 2007-01-02 | Gettelfinger | 120h |
| 13 | 2.2 | Pick surface treatment for standard shims. Prepare shims for additional testing. | 5d | 2007-01-23 | 2007-01-29 | 12 | 2007-01-23 | 2007-01-29 | 5d | 24d | 0d | start no earlier than 2007-01-02 | Gettelfinger | 40h |
| 14 | 2.3 | Perform additional COF tests (LN2 testing, cyclic tests, COF versus normal pressure, etc) for standard shims | 10d | 2007-01-30 | 2007-02-12 | 13 | 2007-01-30 | 2007-02-12 | 10d | 24d | 0d |  | Gettelfinger | 80h |
| 15 | 2.4 | Pick and order material for high COF shims. | 10d | 2007-01-23 | 2007-02-05 | 12 | 2007-01-23 | 2007-02-05 | 10d | 29d | 5d | start no earlier than 2007-01-02 | Gettlefinger | 80h |
| 16 | 2.5 | Perform additional COF tests (LN2 testing, cyclic tests, COF versus normal pressure, etc) for high COF shims | 10d | 2007-02-13 | 2007-02-26 | 15, 14 | 2007-02-13 | 2007-02-26 | 10d | 24d | 0d |  | Gettelfinger | 80h |
| 17 | 2.6 | Document and conduct review of test results | 5d | 2007-02-27 | 2007-03-05 | 16 | 2007-02-27 | 2007-03-05 | 5d | 24d |  |  | Gettlefinger | 40h |
| 19 | 4 | **Tension tests of a bolted joint** | 92d | 2007-01-11 | 2007-05-18 |  | 2007-01-22 | 2007-05-18 | 85d | 7d |  |  |  | 1112h |
| 20 | 4.1 | Develop drawings of prototypical bolted joint for tapped hole and through hole joints | 5d | 2007-01-22 | 2007-01-26 |  | 2007-01-22 | 2007-01-26 | 5d | 115d | 0d | start no earlier than 2007-01-22 | Williamson | 40h |
| 21 | 4.2 | Procure/fab parts for joint test | 15d | 2007-01-29 | 2007-02-16 | 20 | 2007-01-29 | 2007-02-16 | 15d | 115d |  |  | Dudek | 120h |
| 22 | 4.3 | Pick candidate concepts for tightening nuts | 5d | 2007-01-22 | 2007-01-26 |  | 2007-01-22 | 2007-01-26 | 5d | 115d | 0d | start no earlier than 2007-01-22 | Dudek | 40h |
| 23 | 4.4 | Procure tools for tightening nuts | 15d | 2007-01-29 | 2007-02-16 | 22 | 2007-01-29 | 2007-02-16 | 15d | 115d |  |  | Dudek | 120h |
| 24 | 4.5 | Develop design of test fixture and instrumentation | 5d | 2007-01-22 | 2007-01-26 |  | 2007-01-22 | 2007-01-26 | 5d | 0d |  | start no earlier than 2007-01-22 | Gettelfinger | 40h |
| 25 | 4.6 | Set up test fixture and equipment | 15d | 2007-01-29 | 2007-02-16 | 24 | 2007-01-29 | 2007-02-16 | 15d | 0d |  |  | Gettelfinger | 120h |
| 26 | 4.7 | Measure joint deflection v. preload (include UT or SG measurement of bolt tension) | 3d | 2007-02-19 | 2007-02-21 | 25 | 2007-02-19 | 2007-02-21 | 3d | 0d |  |  | Gettlefinger | 24h |
| 27 | 4.8 | Measure joint deflection v. temperature (including candidate washer materials) | 3d | 2007-02-22 | 2007-02-26 | 26 | 2007-02-22 | 2007-02-26 | 3d | 0d |  |  | Gettelfinger | 24h |
| 28 | 4.9 | Measure joint relaxation v. time (days) | 20d | 2007-02-27 | 2007-03-26 | 27 | 2007-02-27 | 2007-03-26 | 20d | 0d |  |  | Gettlefinger | 160h |
| 29 | 4.10 | Measure joint relaxation v. cooldown cycles | 4d | 2007-02-27 | 2007-03-02 | 27 | 2007-02-27 | 2007-03-02 | 4d | 16d |  |  | Gettlefinger | 32h |
| 30 | 4.11 | Perform pullout tests for tapped holes | 4d | 2007-03-27 | 2007-03-30 | 29, 28 | 2007-03-27 | 2007-03-30 | 4d | 0d |  |  | Gettlefinger | 32h |
| 31 | 4.12 | Document and conduct review of test results | 5d | 2007-04-02 | 2007-04-06 | 30, 33 | 2007-04-02 | 2007-04-06 | 5d | 0d |  |  | Gettelfinger | 40h |
| 32 | 4.13 | Procure studs, nuts, and washers | 30d | 2007-04-09 | 2007-05-18 | 31 | 2007-04-09 | 2007-05-18 | 30d | 50d |  |  | Dudek | 240h |
| 33 | 4.14 | Perform analyses to determine geometry and location of high COF shims and placement of new studs | 10d | 2007-01-22 | 2007-02-02 |  | 2007-01-22 | 2007-02-02 | 10d | 40d |  | start no earlier than 2007-01-22 | Brooks | 80h |

| ID | WBS | Task | Duration | Start | Finish | Predecessors | Baseline start | Baseline finish | Baseline duration | Total slack | Free slack | Constraint | Resources | Work |
| --- | --- | --- | --- | --- | --- | --- | --- | --- | --- | --- | --- | --- | --- | --- |
| 35 | 5 | **Bushing tests** | 72d | 2007-01-11 | 2007-04-20 |  | 2007-01-22 | 2007-04-20 | 65d | 27d |  |  |  | 640h |
| 36 | 5.1 | Indentify candidate schemes for getting a bushing the fits tightly into the hole and around a stud. Prepare sketches. | 5d | 2007-01-22 | 2007-01-26 |  | 2007-01-22 | 2007-01-26 | 5d | 20d | 0d | start no earlier than 2007-01-22 | Williamson | 40h |
| 37 | 5.2 | Procure bushing materials for tests. Fabricate bushings. | 15d | 2007-01-29 | 2007-02-16 | 36 | 2007-01-29 | 2007-02-16 | 15d | 20d | 0d |  | Dudek | 120h |
| 38 | 5.3 | Procure tools and materials required for bushing assembly. | 15d | 2007-01-29 | 2007-02-16 | 36 | 2007-01-29 | 2007-02-16 | 15d | 20d | 0d |  | Dudek | 120h |
| 39 | 5.4 | Perform trial bushing installations (short of gluing them in) on a production coil. | 10d | 2007-02-19 | 2007-03-02 | 38, 37 | 2007-02-19 | 2007-03-02 | 10d | 20d | 0d |  | Viola | 80h |
| 40 | 5.5 | Document test results. Select bushing configuration. Conduct peer review of test results and bushing selection. | 5d | 2007-03-05 | 2007-03-09 | 39 | 2007-03-05 | 2007-03-09 | 5d | 20d | 0d |  | Viola | 40h |
| 41 | 5.6 | Procure bushing materials for assembly operations. Fabricate bushings. | 30d | 2007-03-12 | 2007-04-20 | 40 | 2007-03-12 | 2007-04-20 | 30d | 70d |  |  | Dudek | 240h |
| 43 | 6 | **Shear tests of a bolted joint** | 142d | 2007-01-11 | 2007-07-27 |  | 2007-04-09 | 2007-07-27 | 80d | 0d |  |  |  | 640h |
| 44 | 6.1 | Update bolted joint drawings with standard and high COF shims based on friction tests, bushing tests, and tension tests | 10d | 2007-04-09 | 2007-04-20 | 40, 31, 17 | 2007-04-09 | 2007-04-20 | 10d | 0d |  |  | Williamson | 80h |
| 45 | 6.2 | Procure/fab parts for test and initial assembly | 20d | 2007-04-23 | 2007-05-18 | 44 | 2007-04-23 | 2007-05-18 | 20d | 0d |  |  | Dudek | 160h |
| 46 | 6.3 | Set up test fixture | 10d | 2007-05-21 | 2007-06-01 | 45 | 2007-05-21 | 2007-06-01 | 10d | 0d |  |  | Gettlefinger | 80h |
| 47 | 6.4 | Measure joint deflection version shear load. Pull to failure. | 5d | 2007-06-04 | 2007-06-08 | 46 | 2007-06-04 | 2007-06-08 | 5d | 0d |  |  | Gettelfinger | 40h |
| 48 | 6.5 | Document and conduct peer review of test results | 5d | 2007-06-11 | 2007-06-15 | 47 | 2007-06-11 | 2007-06-15 | 5d | 0d |  |  | Gettelfinger | 40h |
| 49 | 6.6 | Procure/fab shims for remaining assembly operations | 30d | 2007-06-18 | 2007-07-27 | 48 | 2007-06-18 | 2007-07-27 | 30d | 0d |  |  | Dudek | 240h |
| 51 | 7 | **Complete design of MC interface hdw** | 1d | 2007-01-11 | 2007-01-11 |  |  |  |  | 141d |  |  |  |  |
| 52 | 7.1 | Establish design criteria for bolted joints | 1d | 2007-01-11 | 2007-01-11 |  |  |  |  | 141d |  |  |  |  |
| 53 | 7.2 | Perform analyses to determine geometry and location of high COF shims and placement of new bolts | 1d | 2007-01-11 | 2007-01-11 |  |  |  |  | 141d |  |  |  |  |
| 54 | 7.3 | Perform structural analyses to establish the adequacy of the proposed design | 1d | 2007-01-11 | 2007-01-11 |  |  |  |  | 141d |  |  |  |  |
| 55 | 7.4 | Develop specs and drawings | 1d | 2007-01-11 | 2007-01-11 |  |  |  |  | 141d |  |  |  |  |
| 56 | 7.5 | Conduct MC interface FDR | 1d | 2007-01-11 | 2007-01-11 |  |  |  |  | 141d |  |  |  |  |
| 57 | 7.6 | Resolve issues, release assembly spec and drawings | 1d | 2007-01-11 | 2007-01-11 |  |  |  |  | 141d |  |  |  |  |
| 59 | 8 | **Complete the design of the tooling and alignment mechanisms** | 1d | 2007-01-11 | 2007-01-11 |  |  |  |  | 141d |  |  |  |  |
| 60 | 8.1 | **Prepare Sta2 for initial operations** | 1d | 2007-01-11 | 2007-01-11 |  |  |  |  | 141d |  |  |  |  |
| 61 | 8.1.1 | Conduct JHA | 1d | 2007-01-11 | 2007-01-11 |  |  |  |  | 141d |  |  |  |  |
| 62 | 8.1.2 | Conduct ACC review of Sta2 | 1d | 2007-01-11 | 2007-01-11 |  |  |  |  | 141d |  |  |  |  |
| 63 | 8.1.3 | Resolve ACC findings | 1d | 2007-01-11 | 2007-01-11 |  |  |  |  | 141d |  |  |  |  |
| 64 | 8.1.4 | Receive RLM authorization for Sta2 initial ops | 1d | 2007-01-11 | 2007-01-11 |  |  |  |  | 141d |  |  |  |  |
| 65 | 8.2 | Perform trial x-y-z alignments on C1-C2. Demonstrate capability to satisfy alignment requirements. | 1d | 2007-01-11 | 2007-01-11 |  |  |  |  | 141d |  |  |  |  |
| 66 | 8.3 | Prototype bladder installation on C1-C2 | 1d | 2007-01-11 | 2007-01-11 |  |  |  |  | 141d |  |  |  |  |
| 67 | 8.4 | Establish alignment mechanisms, metrology equipment complement and positioning requirements, fiducial locations, etc. Conduct peer review. | 1d | 2007-01-11 | 2007-01-11 |  |  |  |  | 141d |  |  |  |  |
| 68 | 8.5 | Procure alignment mechanisms, fiducials, lifting equipment, etc. for assembly operations | 1d | 2007-01-11 | 2007-01-11 |  |  |  |  | 141d |  |  |  |  |

| ID | WBS | Task | Duration | Start | Finish | Baseline start | Baseline finish | Baseline duration | Total slack |
| --- | --- | --- | --- | --- | --- | --- | --- | --- | --- |
| 70 | 9 | **Finalize preparations for assembly operations** | 1d | 2007-01-11 | 2007-01-11 |  |  |  | 141d |
| 71 | 9.1 | Document dimensional control plan | 1d | 2007-01-11 | 2007-01-11 |  |  |  | 141d |
| 72 | 9.2 | Document assembly sequence | 1d | 2007-01-11 | 2007-01-11 |  |  |  | 141d |
| 73 | 9.3 | Finalize assembly procedure | 1d | 2007-01-11 | 2007-01-11 |  |  |  | 141d |
| 74 | 9.4 | Establish back office support requirements and data flow | 1d | 2007-01-11 | 2007-01-11 |  |  |  | 141d |
| 75 | 9.5 | Train technicians in operation of the metrology equipment and measurement procedures | 1d | 2007-01-11 | 2007-01-11 |  |  |  | 141d |
| 76 | 9.6 | Receive RLM authorization for assembly operations | 1d | 2007-01-11 | 2007-01-11 |  |  |  | 141d |
| 79 | 10 | **Finalize design of coil assemblies** | 1d | 2007-01-11 | 2007-01-11 | 2007-01-11 | 2007-01-11 | 1d | 141d |
| 80 | 10.1 | FInalize coolant tube supports and terminations | 1d | 2007-01-11 | 2007-01-11 |  |  |  | 141d |
| 81 | 10.2 | Finalize instrumenation design (TCs and strain gages) | 1d | 2007-01-11 | 2007-01-11 |  |  |  | 141d |
| 82 | 10.3 | Complete coil assembly spec and dwgs | 1d | 2007-01-11 | 2007-01-11 |  |  |  | 141d |
| 83 | 10.4 | Conduct FDR. Resolve issues. Release drawings. | 1d | 2007-01-11 | 2007-01-11 |  |  |  | 141d |
| 84 | 10.5 | Procure hardware required to finish coil assemblies | 1d | 2007-01-11 | 2007-01-11 |  |  |  | 141d |
| 86 | 12 | **Prepare coils for Sta2 operations** | 1d | 2007-01-11 | 2007-01-11 |  |  |  | 141d |
| 87 | 12.1 | Update installation procedures | 1d | 2007-01-11 | 2007-01-11 |  |  |  | 141d |
| 88 | 12.2 | Complete A1 coil | 1d | 2007-01-11 | 2007-01-11 |  |  |  | 141d |
| 89 | 12.3 | Complete A2 coil | 1d | 2007-01-11 | 2007-01-11 |  |  |  | 141d |
| 90 | 12.4 | Pre-fit A1-A2, resolve interferences | 1d | 2007-01-11 | 2007-01-11 |  |  |  | 141d |
| 91 | 12.5 | Complete B1 coil | 1d | 2007-01-11 | 2007-01-11 |  |  |  | 141d |
| 92 | 12.6 | Pre-fit A1-B1, resolve interferences | 1d | 2007-01-11 | 2007-01-11 |  |  |  | 141d |
| 93 | 12.7 | Complete C1 coil | 1d | 2007-01-11 | 2007-01-11 |  |  |  | 141d |
| 94 | 12.8 | Pre-fit B1-C1, resolve interferences | 1d | 2007-01-11 | 2007-01-11 |  |  |  | 141d |
| 96 | 13 | **Start Sta2 assembly operations** | 1d | 2007-01-11 | 2007-01-11 |  |  |  | 141d |
| 97 | 13.1 | Assemble/disassemble A1-A2 | 1d | 2007-01-11 | 2007-01-11 |  |  |  | 141d |
| 98 | 13.2 | Flip A1 | 1d | 2007-01-11 | 2007-01-11 |  |  |  | 141d |
| 99 | 13.3 | Assemble B1-A1 | 1d | 2007-01-11 | 2007-01-11 |  |  |  | 141d |
| 100 | 13.4 | Assemble C1-B1 | 1d | 2007-01-11 | 2007-01-11 |  |  |  | 141d |
| 101 | 13.5 | Remove HP1 (A1-B1-C1) | 1d | 2007-01-11 | 2007-01-11 |  |  |  | 141d |
