Schedule from MS Project MPX, 2007-01-02 to 2007-05-22.

## Calendars

- Standard: Mon-Fri 08:00-12:00, 13:00-17:00; Sat-Sun off.

## Resources

| Resource |
| --- |
| Dudek |
| Fan |
| Williamson |
| Gettelfinger |
| Gettlefinger |
| Brooks |
| Viola |
| Brown |
| Freudenberg |
| DW |
| AB |
| KF |
| Cole |
| Ellis |

## Schedule

| ID | WBS | Task | Type | Duration | Start | Finish | Predecessors | Baseline start | Baseline finish | Baseline duration | Constraint | Resources | Text1 |
| --- | --- | --- | --- | --- | --- | --- | --- | --- | --- | --- | --- | --- | --- |
| 1 | 1 | **Bladder tests** |  | 86.00d | 2007-01-15 | 2007-05-14 |  | 2007-01-15 | 2007-05-14 | 86.00d |  |  |  |
| 2 | 1.1 | Define test plan. Set up test fixture. Order bladders, fill materials, and candidate epoxies for bladder tests. |  | 5.00d | 2007-01-15 | 2007-01-19 |  | 2007-01-15 | 2007-01-19 | 5.00d | start no earlier than 2007-01-15 | Dudek |  |
| 3 | 1.2 | Fill bladder. Perform bench test of Teflon bladder to determine properties. |  | 5.00d | 2007-03-05 | 2007-03-09 | 2, 18 | 2007-03-05 | 2007-03-09 | 5.00d | start no earlier than 2007-01-12 | Gettelfinger | After COF test are finished |
| 4 | 1.3 | Procure/fab prototype bladder for C-C installation |  | 15.00d | 2007-03-12 | 2007-03-30 | 5, 3 | 2007-03-12 | 2007-03-30 | 15.00d |  | Dudek |  |
| 5 | 1.4 | Review structural analyses to determine bladder performance requirements. Verify adequate performance of Teflon bladder. |  | 5.00d | 2007-01-22 | 2007-01-26 |  | 2007-01-22 | 2007-01-26 | 5.00d | start no earlier than 2007-01-22 | Fan |  |
| 6 | 1.5 | Determine if ""one size fits all"". Develop procurement drawings for bladder. |  | 10.00d | 2007-01-22 | 2007-02-02 |  | 2007-01-22 | 2007-02-02 | 10.00d | start no earlier than 2007-01-22 | Williamson |  |
| 7 | 1.6 | Conduct FDR of bladder design |  | 1.00d | 2007-04-09 | 2007-04-09 | 6, 87 | 2007-04-09 | 2007-04-09 | 1.00d |  | Williamson |  |
| 8 | 1.7 | Resolve FDR issues, release procurement drawings for fabrication |  | 5.00d | 2007-04-10 | 2007-04-16 | 7 | 2007-04-10 | 2007-04-16 | 5.00d |  | Williamson |  |
| 9 | 1.8 | Procure bladders for first FPA (2 ea) |  | 20.00d | 2007-04-17 | 2007-05-14 | 8 | 2007-04-17 | 2007-05-14 | 20.00d |  | Dudek |  |
| 10 | 1.9 | Bladders available for FPA | milestone | 0.00d | 2007-05-14 | 2007-05-14 | 9 | 2007-05-14 | 2007-05-14 | 0.00d |  |  |  |
| 12 | 2 | **Shims** |  | 94.00d | 2007-01-02 | 2007-05-11 |  | 2007-01-02 | 2007-05-11 | 94.00d |  |  |  |
| 13 | 2.1 | **Coefficient of friction (COF) tests** |  | 49.00d | 2007-01-02 | 2007-03-09 |  | 2007-01-02 | 2007-03-09 | 49.00d |  |  |  |
| 14 | 2.1.1 | Order candidate materials for screening tests. Perform screening tests. Pick shim surfaces. |  | 19.00d | 2007-01-02 | 2007-01-26 |  | 2007-01-02 | 2007-01-26 | 19.00d | start no earlier than 2007-01-02 | Gettelfinger |  |
| 15 | 2.1.2 | Prepare standard shims for additional testing. |  | 5.00d | 2007-01-29 | 2007-02-02 | 14 | 2007-01-29 | 2007-02-02 | 5.00d | start no earlier than 2007-01-02 | Gettelfinger |  |
| 16 | 2.1.3 | Perform additional COF tests (LN2 testing, cyclic tests, COF versus normal pressure, etc) for standard shims |  | 10.00d | 2007-02-05 | 2007-02-16 | 15 | 2007-02-05 | 2007-02-16 | 10.00d |  | Gettelfinger |  |
| 17 | 2.1.4 | Procure material for high COF shims. |  | 15.00d | 2007-01-29 | 2007-02-16 | 14 | 2007-01-29 | 2007-02-16 | 15.00d | start no earlier than 2007-01-02 | Gettlefinger |  |
| 18 | 2.1.5 | Perform additional COF tests (LN2 testing, cyclic tests, COF versus normal pressure, etc) for high COF shims |  | 10.00d | 2007-02-19 | 2007-03-02 | 17, 16 | 2007-02-19 | 2007-03-02 | 10.00d |  | Gettelfinger |  |
| 19 | 2.1.6 | Document and conduct peer review of test results |  | 5.00d | 2007-03-05 | 2007-03-09 | 18 | 2007-03-05 | 2007-03-09 | 5.00d |  | Gettlefinger |  |
| 20 | 2.1.7 | Shim surfaces defined | milestone | 0.00d | 2007-03-09 | 2007-03-09 | 19 | 2007-03-09 | 2007-03-09 | 0.00d |  |  |  |
| 21 | 2.2 | Define geometry of standard shim |  | 1.00d | 2007-01-19 | 2007-01-19 |  | 2007-01-19 | 2007-01-19 | 1.00d | start no earlier than 2007-01-19 | Williamson |  |
| 22 | 2.3 | Finalize procurement drawings. Conduct FDR |  | 5.00d | 2007-03-12 | 2007-03-16 | 20, 21 | 2007-03-12 | 2007-03-16 | 5.00d |  |  |  |
| 23 | 2.4 | Procure shims |  | 40.00d | 2007-03-19 | 2007-05-11 | 22 | 2007-03-19 | 2007-05-11 | 40.00d |  |  |  |
| 24 | 2.5 | Shims available for FPA | milestone | 0.00d | 2007-05-11 | 2007-05-11 | 23 | 2007-05-11 | 2007-05-11 | 0.00d |  |  |  |
| 26 | 4 | **Tension tests of a bolted joint** |  | 80.00d | 2007-01-22 | 2007-05-11 |  | 2007-01-22 | 2007-05-11 | 80.00d |  |  |  |
| 27 | 4.1 | **Procure nuts, studs, and washers ASAP** |  | 80.00d | 2007-01-22 | 2007-05-11 |  | 2007-01-22 | 2007-05-11 | 80.00d |  |  |  |
| 28 | 4.1.1 | Choose tools for tightening nuts |  | 80.00d | 2007-01-22 | 2007-05-11 |  | 2007-01-22 | 2007-05-11 | 80.00d |  |  |  |
| 29 | 4.1.1 | Choose tools for tightening nuts |  | 5.00d | 2007-01-22 | 2007-01-26 |  | 2007-01-22 | 2007-01-26 | 5.00d | start no earlier than 2007-01-22 |  |  |
| 30 | 4.1.2 | Perform analyses to determine geometry and location of high COF shims and placement of new studs. Characterize performance impacts of Low CTE washers. |  | 80.00d | 2007-01-22 | 2007-05-11 |  | 2007-01-22 | 2007-05-11 | 80.00d |  |  |  |
| 31 | 4.1.2 | Perform analyses to determine geometry and location of high COF shims and placement of new studs. Characterize performance impacts of Low CTE washers. |  | 10.00d | 2007-01-22 | 2007-02-02 |  | 2007-01-22 | 2007-02-02 | 10.00d | start no earlier than 2007-01-22 | Brooks |  |
| 32 | 4.1.3 | Modify current drawing to accommodate hydraulic tensioners and UT inspection. Establish number for each length. |  | 5.00d | 2007-02-12 | 2007-02-16 | 29, 31, 75 | 2007-02-12 | 2007-02-16 | 5.00d | start no earlier than 2007-01-22 | Williamson | High priority |
| 33 | 4.1.4 | Develop cost and lead time estimates for nuts, studs, and washers of different materials. |  | 10.00d | 2007-01-22 | 2007-02-02 |  | 2007-01-22 | 2007-02-02 | 10.00d | start no earlier than 2007-01-22 | Williamson |  |
| 34 | 4.1.5 | Complete procurement drawings. Conduct peer review prior to long lead procurement. |  | 10.00d | 2007-02-19 | 2007-03-02 | 32, 33 | 2007-02-19 | 2007-03-02 | 10.00d |  | Williamson |  |
| 35 | 4.1.6 | Procure nuts studs and washers for start of FPA |  | 50.00d | 2007-03-05 | 2007-05-11 | 34 | 2007-03-05 | 2007-05-11 | 50.00d | start no earlier than 2007-01-22 | Williamson |  |
| 36 | 4.1.7 | Nuts, studs, and washers available for FPA | milestone | 0.00d | 2007-05-11 | 2007-05-11 | 35 | 2007-05-11 | 2007-05-11 | 0.00d |  |  |  |
| 37 | 4.2 | Develop drawings of prototypical bolted joint for tapped hole and through hole joints |  | 5.00d | 2007-02-19 | 2007-02-23 | 32 | 2007-02-19 | 2007-02-23 | 5.00d | start no earlier than 2007-01-22 | Williamson |  |
| 38 | 4.3 | Procure/fab parts for joint test. Use existing parts where possible |  | 15.00d | 2007-02-26 | 2007-03-16 | 37 | 2007-02-26 | 2007-03-16 | 15.00d |  | Dudek |  |
| 39 | 4.4 | Procure tools for tightening nuts |  | 15.00d | 2007-01-29 | 2007-02-16 | 29 | 2007-01-29 | 2007-02-16 | 15.00d |  | Dudek |  |
| 40 | 4.5 | Develop design of test fixture and instrumentation |  | 5.00d | 2007-03-12 | 2007-03-16 | 37, 3 | 2007-03-12 | 2007-03-16 | 5.00d | start no earlier than 2007-01-22 | Gettelfinger | After bladder tests are complete |
| 41 | 4.6 | Set up test fixture and equipment. Perform JHA and pre-job brief prior to proceeding. |  | 10.00d | 2007-03-19 | 2007-03-30 | 40, 39 | 2007-03-19 | 2007-03-30 | 10.00d |  | Gettelfinger |  |
| 42 | 4.7 | Measure joint deflection v. preload (include UT or SG measurement of bolt tension). Measure loss of preload after hydraulic pressure is removed. |  | 3.00d | 2007-04-02 | 2007-04-04 | 41 | 2007-04-02 | 2007-04-04 | 3.00d |  | Gettlefinger |  |
| 43 | 4.8 | Cool joint to 80K. Measure joint deflection and preload v. temperature (including candidate washer materials) |  | 3.00d | 2007-04-05 | 2007-04-09 | 42 | 2007-04-05 | 2007-04-09 | 3.00d |  | Gettelfinger |  |
| 44 | 4.9 | Measure joint deflection and preload v. time (days) at RT and 80K |  | 20.00d | 2007-04-02 | 2007-04-27 | 41 | 2007-04-02 | 2007-04-27 | 20.00d |  | Gettlefinger |  |
| 45 | 4.10 | Measure joint deflection and preload v. cooldown cycles |  | 3.00d | 2007-04-10 | 2007-04-12 | 43 | 2007-04-10 | 2007-04-12 | 3.00d |  | Gettlefinger |  |
| 46 | 4.11 | Perform pullout tests for tapped holes |  | 3.00d | 2007-04-13 | 2007-04-17 | 45 | 2007-04-13 | 2007-04-17 | 3.00d |  | Gettlefinger |  |
| 47 | 4.12 | Document and conduct review of test results |  | 5.00d | 2007-04-30 | 2007-05-04 | 46, 44 | 2007-04-30 | 2007-05-04 | 5.00d |  | Gettelfinger |  |

| ID | WBS | Task | Type | Duration | Start | Finish | Predecessors | Baseline start | Baseline finish | Baseline duration | Constraint | Resources |
| --- | --- | --- | --- | --- | --- | --- | --- | --- | --- | --- | --- | --- |
| 49 | 5 | **Bushing tests** |  | 65.00d | 2007-01-22 | 2007-04-20 |  | 2007-01-22 | 2007-04-20 | 65.00d |  |  |
| 50 | 5.1 | Indentify candidate schemes for getting a bushing the fits tightly into the hole and around a stud. Prepare sketches. |  | 5.00d | 2007-01-22 | 2007-01-26 |  | 2007-01-22 | 2007-01-26 | 5.00d | start no earlier than 2007-01-22 | Williamson |
| 51 | 5.2 | Procure bushing materials for tests. Fabricate bushings. |  | 15.00d | 2007-01-29 | 2007-02-16 | 50 | 2007-01-29 | 2007-02-16 | 15.00d | start no earlier than 2007-01-22 | Dudek |
| 52 | 5.3 | Procure tools and materials required for bushing assembly. |  | 15.00d | 2007-01-29 | 2007-02-16 | 50 | 2007-01-29 | 2007-02-16 | 15.00d |  | Dudek |
| 53 | 5.4 | Perform trial bushing installations (short of gluing them in) on a production coil. |  | 10.00d | 2007-02-19 | 2007-03-02 | 52, 51 | 2007-02-19 | 2007-03-02 | 10.00d |  | Viola |
| 54 | 5.5 | Document test results. Select bushing configuration. Conduct peer review of test results and bushing selection. |  | 5.00d | 2007-03-05 | 2007-03-09 | 53 | 2007-03-05 | 2007-03-09 | 5.00d |  | Viola |
| 55 | 5.6 | Procure bushing materials for assembly operations. Fabricate bushings. |  | 30.00d | 2007-03-12 | 2007-04-20 | 54 | 2007-03-12 | 2007-04-20 | 30.00d |  | Dudek |
| 56 | 5.7 | Bushings available for FPA operations | milestone | 0.00d | 2007-04-20 | 2007-04-20 | 55 | 2007-04-20 | 2007-04-20 | 0.00d |  |  |
| 58 | 6 | **Shear tests of a bolted joint** |  | 42.00d | 2007-03-19 | 2007-05-15 |  | 2007-03-19 | 2007-05-15 | 42.00d |  |  |
| 59 | 6.1 | Procure/fab parts for test and initial assembly |  | 20.00d | 2007-03-19 | 2007-04-13 | 22, 34, 54 | 2007-03-19 | 2007-04-13 | 20.00d |  | Dudek |
| 60 | 6.2 | Set up test fixture |  | 10.00d | 2007-04-18 | 2007-05-01 | 59, 46 | 2007-04-18 | 2007-05-01 | 10.00d |  | Gettlefinger |
| 61 | 6.3 | Measure joint deflection version shear load. Pull to failure. |  | 5.00d | 2007-05-02 | 2007-05-08 | 60 | 2007-05-02 | 2007-05-08 | 5.00d |  | Gettelfinger |
| 62 | 6.4 | Document test results |  | 5.00d | 2007-05-09 | 2007-05-15 | 61 | 2007-05-09 | 2007-05-15 | 5.00d |  | Gettelfinger |
| 64 | 7 | **Complete design of MC interface hdw** |  | 87.00d | 2007-01-22 | 2007-05-22 |  | 2007-01-22 | 2007-05-22 | 87.00d |  |  |
| 65 | 7.1 | Establish design criteria for bolted joints |  | 5.00d | 2007-01-22 | 2007-01-26 |  | 2007-01-22 | 2007-01-26 | 5.00d | start no earlier than 2007-01-22 | Fan |
| 66 | 7.2 | Perform analyses to determine geometry and location of high COF shims and placement of new bolts |  | 10.00d | 2007-01-22 | 2007-02-02 |  | 2007-01-22 | 2007-02-02 | 10.00d | start no earlier than 2007-01-22 | Brooks |
| 67 | 7.3 | Perform structural analyses to performance requirements for bolted joints |  | 10.00d | 2007-01-22 | 2007-02-02 |  | 2007-01-22 | 2007-02-02 | 10.00d | start no earlier than 2007-01-22 | AB; KF |
| 68 | 7.4 | Define reference bolted joint design |  | 5.00d | 2007-01-22 | 2007-01-26 |  | 2007-01-22 | 2007-01-26 | 5.00d | start no earlier than 2007-01-22 | Williamson |
| 69 | 7.5 | Conduct PDR to review requirements, design, and development plan |  | 1.00d | 2007-02-05 | 2007-02-05 | 14, 66, 67, 68 | 2007-02-05 | 2007-02-05 | 1.00d |  | Williamson |
| 70 | 7.6 | Develop specs and drawings for Station 2 and 3 assemblies |  | 15.00d | 2007-03-19 | 2007-04-06 | 22, 34, 54 | 2007-03-19 | 2007-04-06 | 15.00d |  | Cole |
| 71 | 7.7 | Conduct MC interface FDR | milestone | 0.00d | 2007-05-15 | 2007-05-15 | 70, 62, 47 | 2007-05-15 | 2007-05-15 | 0.00d |  | Williamson |
| 72 | 7.8 | Resolve issues, release assembly spec and drawings |  | 5.00d | 2007-05-16 | 2007-05-22 | 71 | 2007-05-16 | 2007-05-22 | 5.00d |  | Williamson |
| 74 | 8 | **Perform assembly trials. Procure tools and tooling.** |  | 70.00d | 2007-01-22 | 2007-04-27 |  | 2007-01-22 | 2007-04-27 | 70.00d |  |  |
| 75 | 8.1 | Survey each coil type using templates. Determine stud length constraints based on access limitations for torquing/tensioning. |  | 10.00d | 2007-01-29 | 2007-02-09 | 29 | 2007-01-29 | 2007-02-09 | 10.00d |  | Viola |

| ID | WBS | Task | Type | Duration | Start | Finish | Predecessors | Baseline start | Baseline finish | Baseline duration | Constraint | Resources |
| --- | --- | --- | --- | --- | --- | --- | --- | --- | --- | --- | --- | --- |
| 76 | 8.2 | **Identify areas that need to be measured in post-VPI and ground** |  | 20.00d | 2007-01-22 | 2007-02-16 |  | 2007-01-22 | 2007-02-16 | 20.00d |  |  |
| 77 | 8.2.1 | Identify ""close points"" when assembling |  | 5.00d | 2007-01-22 | 2007-01-26 |  | 2007-01-22 | 2007-01-26 | 5.00d | start no earlier than 2007-01-22 | Brown |
| 78 | 8.2.2 | Perform fits of C-C, C-B, B-A, and A-A |  | 15.00d | 2007-01-22 | 2007-02-09 |  | 2007-01-22 | 2007-02-09 | 15.00d | start no earlier than 2007-01-22 | Viola |
| 79 | 8.2.3 | Provide guidance to revise post-VPI procedure to include measurement points |  | 5.00d | 2007-02-12 | 2007-02-16 | 77, 78 | 2007-02-12 | 2007-02-16 | 5.00d |  | Brown |
| 80 | 8.3 | Perform trial x-y-z alignments on C1-C2. Demonstrate capability to satisfy alignment requirements with individual shims of uniform thickness. |  | 10.00d | 2007-02-12 | 2007-02-23 | 78 | 2007-02-12 | 2007-02-23 | 10.00d |  | Viola |
| 81 | 8.4 | Establish alignment mechanisms, metrology equipment complement and positioning requirements, etc. Conduct peer review. |  | 5.00d | 2007-02-26 | 2007-03-02 | 80 | 2007-02-26 | 2007-03-02 | 5.00d |  | Viola |
| 82 | 8.5 | Procure alignment mechanisms, fiducials, lifting equipment, etc. for assembly operations |  | 40.00d | 2007-03-05 | 2007-04-27 | 81 | 2007-03-05 | 2007-04-27 | 40.00d |  | Dudek |
| 83 | 8.6 | Develop procedures for torquing bolts |  | 5.00d | 2007-02-26 | 2007-03-02 | 80, 39 | 2007-02-26 | 2007-03-02 | 5.00d |  | Viola |
| 84 | 8.7 | Determine fiducial types and locations |  | 10.00d | 2007-03-05 | 2007-03-16 | 83 | 2007-03-05 | 2007-03-16 | 10.00d |  | Viola |
| 85 | 8.8 | Procure monuments and related metrology equipment |  | 30.00d | 2007-03-19 | 2007-04-27 | 84 | 2007-03-19 | 2007-04-27 | 30.00d |  | Dudek |
| 86 | 8.9 | Tools and tooling available for FPA operations | milestone | 0.00d | 2007-04-27 | 2007-04-27 | 39, 82, 85 | 2007-04-27 | 2007-04-27 | 0.00d |  |  |
| 87 | 8.10 | Prototype bladder installation. |  | 5.00d | 2007-04-02 | 2007-04-06 | 4 | 2007-04-02 | 2007-04-06 | 5.00d |  | Viola |
| 89 | 9 | **Finalize preparations for assembly operations** |  | 20.00d | 2007-04-18 | 2007-05-15 |  | 2007-04-18 | 2007-05-15 | 20.00d |  |  |
| 90 | 9.1 | Document assembly sequence |  | 5.00d | 2007-04-18 | 2007-04-24 | 7, 22, 46, 54 | 2007-04-18 | 2007-04-24 | 5.00d |  | Ellis |
| 91 | 9.2 | Finalize dimensional control plan |  | 5.00d | 2007-04-25 | 2007-05-01 | 90 | 2007-04-25 | 2007-05-01 | 5.00d |  | Brown |
| 92 | 9.3 | Finalize assembly procedure |  | 5.00d | 2007-05-02 | 2007-05-08 | 91 | 2007-05-02 | 2007-05-08 | 5.00d |  | Viola |
| 93 | 9.4 | Establish back office support requirements and data flow |  | 5.00d | 2007-05-09 | 2007-05-15 | 92 | 2007-05-09 | 2007-05-15 | 5.00d |  | Viola |
| 94 | 9.5 | Train technicians in operation of the metrology equipment and measurement procedures |  | 5.00d | 2007-05-09 | 2007-05-15 | 92 | 2007-05-09 | 2007-05-15 | 5.00d |  | Viola |
| 95 | 9.6 | RLM authorization for assembly operations | milestone | 0.00d | 2007-05-15 | 2007-05-15 | 93, 94 | 2007-05-15 | 2007-05-15 | 0.00d |  | Dudek |
| 97 | 10 | Start Station 2 assembly operations | milestone | 0.00d | 2007-05-15 | 2007-05-15 | 10, 24, 56, 71, 86, 95 | 2007-05-15 | 2007-05-15 | 0.00d |  | Viola |
