# FPA Station 2 db

Schedule from MS Project, 2006-11-01 to 2008-06-24.
PPPL

## Calendars

- Standard: Mon-Fri 08:00-12:00, 13:00-17:00; Sat-Sun off.

## Resources

| Resource |
| --- |
| S2P1 |
| S2P2 |
| S2P3 |

## Schedule

| ID | Task | Type | Duration | Start | Finish | Total slack | Constraint | Resources | Work |
| --- | --- | --- | --- | --- | --- | --- | --- | --- | --- |
| 1 | Receive MTM Fixtures |  | 4d | 2007-01-02 | 2007-01-05 | 382d | start no earlier than 2007-01-02 | S2P1 | 32h |
| 2 | Modify MTM Fixtures |  | 4d | 2007-01-09 | 2007-01-12 | 377d | start no earlier than 2007-01-09 | S2P1 | 32h |
| 3 | Prototype Stycast injection |  | 29d | 2007-01-02 | 2007-02-09 | 357d | start no earlier than 2007-01-02 | S2P1 | 232h |
| 4 | Determine compression of G-11 |  | 1d | 2007-01-02 | 2007-01-02 | 385d | start no earlier than 2007-01-02 | S2P1 | 8h |
| 5 | Pre-fit C2-C3 |  | 2d | 2006-11-01 | 2006-11-02 | 428d | start no earlier than 2006-11-01 | S2P1 | 16h |
| 6 | Rework C2-C3 |  | 4d | 2006-11-06 | 2006-11-09 | 423d | start no earlier than 2006-11-06 | S2P1 | 32h |
| 7 | Pre-fit C1-B1 |  | 2d | 2007-03-01 | 2007-03-02 | 342d | start no earlier than 2007-03-01 | S2P1 | 16h |
| 8 | Rework C1-B1 |  | 4d | 2007-03-06 | 2007-03-09 | 337d | start no earlier than 2007-03-06 | S2P1 | 32h |
| 9 | Pre-fit B1-A1 |  | 2d | 2007-03-01 | 2007-03-02 | 342d | start no earlier than 2007-03-01 | S2P1 | 16h |
| 10 | Rework B1-A1 |  | 4d | 2007-03-06 | 2007-03-09 | 337d | start no earlier than 2007-03-06 | S2P1 | 32h |
| 11 | Pre-fit A1-A2 |  | 2d | 2006-12-19 | 2006-12-20 | 394d | start no earlier than 2006-12-19 | S2P1 | 16h |
| 12 | Rework A1-A2 |  | 10d | 2006-12-22 | 2007-01-04 | 383d | start no earlier than 2006-12-22 | S2P1 | 80h |
| 13 | Pre-fit A2-B2 |  | 1d | 2007-06-01 | 2007-06-01 | 277d | start no earlier than 2007-06-01 | S2P1 | 8h |
| 14 | Rework A2-B2 |  | 4d | 2007-06-05 | 2007-06-08 | 272d | start no earlier than 2007-06-05 | S2P1 | 32h |
| 15 | Pre-fit B2-C2 |  | 1d | 2007-06-01 | 2007-06-01 | 277d | start no earlier than 2007-06-01 | S2P1 | 8h |
| 16 | Rework B2-C2 |  | 4d | 2007-06-05 | 2007-06-08 | 272d | start no earlier than 2007-06-05 | S2P1 | 32h |
| 17 | Test out equipt & procedures |  | 5d | 2007-01-16 | 2007-01-22 | 371d | start no earlier than 2007-01-16 | S2P1 | 40h |
| 18 | A1-A2 Fitup |  | 31d | 2007-03-13 | 2007-04-24 | 305d | start no earlier than 2007-03-13 | S2P1 | 248h |
| 19 | A1-B1 Fitup |  | 32d | 2007-04-26 | 2007-06-08 | 272d | start no earlier than 2007-04-26 | S2P1 | 256h |
| 20 | A1-B1 Join |  | 8d | 2007-06-12 | 2007-06-21 | 263d | start no earlier than 2007-06-12 | S2P1 | 64h |
| 21 | B1-C1 Fitup |  | 32d | 2007-06-25 | 2007-08-07 | 230d | start no earlier than 2007-06-25 | S2P1 | 256h |
| 22 | B1-C1 Join |  | 8d | 2007-08-09 | 2007-08-20 | 221d | start no earlier than 2007-08-09 | S2P1 | 64h |
| 23 | A1-B1-C1 Setup injection sys & Pot |  | 9d | 2007-08-22 | 2007-09-03 | 211d | start no earlier than 2007-08-22 | S2P1 | 72h |
| 24 | A1-B1-C1 Cure and remove |  | 2d | 2007-09-05 | 2007-09-06 | 208d | start no earlier than 2007-09-05 | S2P1 | 16h |
| 25 | A2-B2 Fitup |  | 25d | 2007-06-12 | 2007-07-16 | 246d | start no earlier than 2007-06-12 | S2P1 | 200h |
| 26 | A2-B2 Join |  | 6d | 2007-07-18 | 2007-07-25 | 239d | start no earlier than 2007-07-18 | S2P1 | 48h |
| 27 | B2-C2 Fitup |  | 24d | 2007-07-27 | 2007-08-29 | 214d | start no earlier than 2007-07-27 | S2P1 | 192h |
| 28 | B2-C2 Join |  | 7d | 2007-08-31 | 2007-09-10 | 206d | start no earlier than 2007-08-31 | S2P1 | 56h |
| 29 | A2-B2-C2 Setup injection sys & Pot |  | 6d | 2007-09-12 | 2007-09-19 | 199d | start no earlier than 2007-09-12 | S2P1 | 48h |
| 30 | A2-B2-C2 Cure and remove |  | 2d | 2007-09-21 | 2007-09-24 | 196d | start no earlier than 2007-09-21 | S2P1 | 16h |
| 31 | C2-C3 Fitup |  | 24d | 2007-09-26 | 2007-10-29 | 171d | start no earlier than 2007-09-26 | S2P1 | 192h |
| 32 | Pre-fit C4-C5 | milestone | 0d | 2006-11-01 | 2006-11-01 | 430d | start no earlier than 2006-11-01 | S2P2 |  |
| 33 | Rework C4-C5 |  | 4d | 2006-11-02 | 2006-11-07 | 425d | start no earlier than 2006-11-02 | S2P2 | 32h |
| 34 | Pre-fit C3-B3 |  | 2d | 2007-06-28 | 2007-06-29 | 257d | start no earlier than 2007-06-28 | S2P2 | 16h |
| 35 | Rework C3-B3 |  | 5d | 2007-07-03 | 2007-07-09 | 251d | start no earlier than 2007-07-03 | S2P2 | 40h |
| 36 | Pre-fit B3-A3 |  | 2d | 2007-06-28 | 2007-06-29 | 257d | start no earlier than 2007-06-28 | S2P2 | 16h |
| 37 | Rework B3-A3 |  | 5d | 2007-07-03 | 2007-07-09 | 251d | start no earlier than 2007-07-03 | S2P2 | 40h |
| 38 | Pre-fit A3-A4 |  | 2d | 2007-05-04 | 2007-05-07 | 296d | start no earlier than 2007-05-04 | S2P2 | 16h |
| 39 | Rework A3-A4 |  | 4d | 2007-05-09 | 2007-05-14 | 291d | start no earlier than 2007-05-09 | S2P2 | 32h |
| 40 | Pre-fit A4-B4 |  | 1d | 2007-07-26 | 2007-07-26 | 238d | start no earlier than 2007-07-26 | S2P2 | 8h |
| 41 | Rework A4-B4 |  | 4d | 2007-07-30 | 2007-08-02 | 233d | start no earlier than 2007-07-30 | S2P2 | 32h |
| 42 | Pre-fit B4-C4 |  | 1d | 2007-07-26 | 2007-07-26 | 238d | start no earlier than 2007-07-26 | S2P2 | 8h |
| 43 | Rework B4-C4 |  | 4d | 2007-07-30 | 2007-08-02 | 233d | start no earlier than 2007-07-30 | S2P2 | 32h |
| 44 | A3-A4 Fitup |  | 24d | 2007-09-10 | 2007-10-11 | 183d | start no earlier than 2007-09-10 | S2P2 | 192h |
| 45 | A3-B3 Fitup |  | 24d | 2007-10-15 | 2007-11-15 | 158d | start no earlier than 2007-10-15 | S2P2 | 192h |
| 46 | A3-B3 Join |  | 6d | 2007-11-19 | 2007-11-26 | 151d | start no earlier than 2007-11-19 | S2P2 | 48h |
| 47 | B3-C3 Fitup |  | 33d | 2007-11-28 | 2008-01-11 | 117d | start no earlier than 2007-11-28 | S2P2 | 264h |
| 48 | B3-C3 Join |  | 6d | 2008-01-15 | 2008-01-22 | 110d | start no earlier than 2008-01-15 | S2P2 | 48h |
| 49 | A3-B3-C3 Setup injection sys & Pot |  | 6d | 2008-01-24 | 2008-01-31 | 103d | start no earlier than 2008-01-24 | S2P2 | 48h |
| 50 | A3-B3-C3 Cure and remove |  | 2d | 2008-02-04 | 2008-02-05 | 100d | start no earlier than 2008-02-04 | S2P2 | 16h |
| 51 | A4-B4 Fitup |  | 24d | 2007-09-26 | 2007-10-29 | 171d | start no earlier than 2007-09-26 | S2P2 | 192h |
| 52 | A4-B4 Join |  | 6d | 2007-10-31 | 2007-11-07 | 164d | start no earlier than 2007-10-31 | S2P2 | 48h |
| 53 | B4-C4 Fitup |  | 26d | 2007-11-09 | 2007-12-14 | 137d | start no earlier than 2007-11-09 | S2P2 | 208h |
| 54 | B4-C4 Join |  | 13d | 2007-12-18 | 2008-01-03 | 123d | start no earlier than 2007-12-18 | S2P2 | 104h |
| 55 | A4-B4-C4 Setup injection sys & Pot |  | 6d | 2008-01-07 | 2008-01-14 | 116d | start no earlier than 2008-01-07 | S2P2 | 48h |
| 56 | A4-B4-C4 Cure and remove |  | 2d | 2008-01-16 | 2008-01-17 | 113d | start no earlier than 2008-01-16 | S2P2 | 16h |
| 57 | C4-C5 Fitup |  | 24d | 2008-01-21 | 2008-02-21 | 88d | start no earlier than 2008-01-21 | S2P2 | 192h |
| 58 | Pre-fit C6-C1 |  | 2d | 2007-12-18 | 2007-12-19 | 134d | start no earlier than 2007-12-18 | S2P3 | 16h |
| 59 | Rework C6-C1 |  | 11d | 2007-12-21 | 2008-01-04 | 122d | start no earlier than 2007-12-21 | S2P3 | 88h |
| 60 | Pre-fit C5-B5 |  | 2d | 2007-08-22 | 2007-08-23 | 218d | start no earlier than 2007-08-22 | S2P3 | 16h |
| 61 | Rework C5-B5 |  | 4d | 2007-08-27 | 2007-08-30 | 213d | start no earlier than 2007-08-27 | S2P3 | 32h |
| 62 | Pre-fit B5-A5 |  | 2d | 2007-10-16 | 2007-10-17 | 179d | start no earlier than 2007-10-16 | S2P3 | 16h |
| 63 | Rework B5-A5 |  | 4d | 2007-10-19 | 2007-10-24 | 174d | start no earlier than 2007-10-19 | S2P3 | 32h |
| 64 | Pre-fit A5-A6 |  | 2d | 2007-11-19 | 2007-11-20 | 155d | start no earlier than 2007-11-19 | S2P3 | 16h |
| 65 | Rework A5-A6 |  | 4d | 2007-11-22 | 2007-11-27 | 150d | start no earlier than 2007-11-22 | S2P3 | 32h |
| 66 | Pre-fit A6-B6 |  | 2d | 2007-11-19 | 2007-11-20 | 155d | start no earlier than 2007-11-19 | S2P3 | 16h |
| 67 | Rework A6-B6 |  | 4d | 2007-11-22 | 2007-11-27 | 150d | start no earlier than 2007-11-22 | S2P3 | 32h |
| 68 | Pre-fit B6-C6 |  | 2d | 2007-12-18 | 2007-12-19 | 134d | start no earlier than 2007-12-18 | S2P3 | 16h |
| 69 | Rework B6-C6 |  | 11d | 2007-12-21 | 2008-01-04 | 122d | start no earlier than 2007-12-21 | S2P3 | 88h |
| 70 | A5-A6 Fitup |  | 24d | 2008-02-07 | 2008-03-11 | 75d | start no earlier than 2008-02-07 | S2P3 | 192h |

| ID | Task | Duration | Start | Finish | Total slack | Constraint | Resources | Work |
| --- | --- | --- | --- | --- | --- | --- | --- | --- |
| 71 | A5-B5 Fitup | 24d | 2008-03-13 | 2008-04-15 | 50d | start no earlier than 2008-03-13 | S2P3 | 192h |
| 72 | A5-B5 Join | 6d | 2008-04-17 | 2008-04-24 | 43d | start no earlier than 2008-04-17 | S2P3 | 48h |
| 73 | B5-C5 Fitup | 25d | 2008-04-28 | 2008-05-30 | 17d | start no earlier than 2008-04-28 | S2P3 | 200h |
| 74 | B5-C5 Join | 6d | 2008-06-03 | 2008-06-10 | 10d | start no earlier than 2008-06-03 | S2P3 | 48h |
| 75 | A5-B5-C5 Setup injection sys & Pot | 6d | 2008-06-12 | 2008-06-19 | 3d | start no earlier than 2008-06-12 | S2P3 | 48h |
| 76 | A5-B5-C5 Cure and remove | 2d | 2008-06-23 | 2008-06-24 | 0d | start no earlier than 2008-06-23 | S2P3 | 16h |
| 77 | A6-B6 Fitup | 24d | 2008-01-21 | 2008-02-21 | 88d | start no earlier than 2008-01-21 | S2P3 | 192h |
| 78 | A6-B6 Join | 6d | 2008-02-25 | 2008-03-03 | 81d | start no earlier than 2008-02-25 | S2P3 | 48h |
| 79 | B6-C6 Fitup | 24d | 2008-03-05 | 2008-04-07 | 56d | start no earlier than 2008-03-05 | S2P3 | 192h |
| 80 | B6-C6 Join | 6d | 2008-04-09 | 2008-04-16 | 49d | start no earlier than 2008-04-09 | S2P3 | 48h |
| 81 | A6-B6-C6 Setup injection sys & Pot | 6d | 2008-04-18 | 2008-04-25 | 42d | start no earlier than 2008-04-18 | S2P3 | 48h |
| 82 | A6-B6-C6 Cure and remove | 2d | 2008-04-29 | 2008-04-30 | 39d | start no earlier than 2008-04-29 | S2P3 | 16h |
| 83 | C6-C1 Fitup | 25d | 2008-05-02 | 2008-06-05 | 13d | start no earlier than 2008-05-02 | S2P3 | 200h |
